# е-ресторани-план

Schedule from MS Project, 2014-10-07 to 2015-05-01, costs in ден., A marks actual dates.

## Calendars

- Standard: Mon-Fri 08:00-12:00, 13:00-17:00; Sat-Sun off.

## Resources

| Resource | Rate |
| --- | --- |
| Елена Камчевска | 1000 |
| Влатко Симоновски | 1000 |
| Развивач 1 | 2000 |
| Развивач 2 | 2000 |

## Schedule

| ID | WBS | Task | Duration | Start | Finish | Predecessors | Complete | Remaining | Total slack | Free slack | Constraint | Deadline | Resources | Work | Actual work | Cost | Actual cost |
| --- | --- | --- | --- | --- | --- | --- | --- | --- | --- | --- | --- | --- | --- | --- | --- | --- | --- |
| 1 | 1 | **Фаза 1: Inception** | 31.5d | 2014-10-07 A | 2014-11-19 |  | 3% | 30.56d | 52.5d |  |  |  |  | 316h | 8h | 316,000 | 8,000 |
| 2 | 1.1 | Опис на проект, став за проблематиката и организација на проектен сајт | 3.5d | 2014-10-07 | 2014-10-10 |  |  |  | 80.5d |  | start no earlier than 2014-10-07 |  | Елена Камчевска; Влатко Симоновски | 56h |  | 56,000 |  |
| 3 | 1.2 | анализа на проблемот | 2.5d | 2014-10-09 | 2014-10-13 |  |  |  | 79.5d |  | start no earlier than 2014-10-09 |  | Елена Камчевска; Влатко Симоновски | 40h |  | 40,000 |  |
| 4 | 1.3 | дефинирање на потребите на стеикходерите | 4d | 2014-10-13 | 2014-10-16 |  |  |  | 32d |  | start no earlier than 2014-10-11 |  | Влатко Симоновски | 32h |  | 32,000 |  |
| 5 | 1.4 | креирање визија | 4d | 2014-10-17 | 2014-10-22 |  |  |  | 72d |  | start no earlier than 2014-10-17 |  | Елена Камчевска | 32h |  | 32,000 |  |
| 6 | 1.5 | дефинирање на актери и кориснички случаи | 5d | 2014-10-23 | 2014-10-29 |  |  |  | -1d | 0d | start no earlier than 2014-10-23 | 2014-10-28 | Влатко Симоновски | 40h |  | 40,000 |  |
| 7 | 1.6 | креирање use-case модели | 4d | 2014-10-30 | 2014-11-04 |  |  |  | 0d |  | finish no earlier than 2014-11-04 | 2014-11-04 | Елена Камчевска | 32h |  | 32,000 |  |
| 8 | 1.7 | креирање почетен проектен план | 5d | 2014-11-05 A | 2014-11-11 |  | 20% | 4d | 58d |  | start no earlier than 2014-11-05 |  | Елена Камчевска | 40h | 8h | 40,000 | 8,000 |
| 9 | 1.8 | план за итерација | 5.5d | 2014-11-12 A | 2014-11-19 |  |  | 5.5d | 52.5d |  | finish no earlier than 2014-11-14 |  | Елена Камчевска | 44h |  | 44,000 |  |
| 10 | 2 | **Фаза 2: Elaboration** | 56d? | 2014-11-14 | 2015-01-30 |  |  |  | 12d |  |  |  |  | 448h |  | 448,000 |  |
| 11 | 2.1 | операциона анализа на кориснички случаи | 3d? | 2014-11-14 | 2014-11-18 |  |  |  | 50d | 0d | finish no earlier than 2014-11-18 |  | Влатко Симоновски | 24h |  | 24,000 |  |
| 12 | 2.2 | креирање проектен план (дополнување) | 3d? | 2014-11-19 | 2014-11-21 | 11 |  |  | 50d |  | start no earlier than 2014-11-19 |  | Елена Камчевска | 24h |  | 24,000 |  |
| 13 | 2.3 | **детален use-case модел** | 14d? | 2014-11-26 | 2014-12-15 |  |  |  | 99d |  |  |  |  | 136h |  | 136,000 |  |
| 14 | 2.3.1 | детализирање на "Креирање резервација" | 2d | 2014-11-26 | 2014-11-27 |  |  |  | 44d | 0d | finish no earlier than 2014-11-27 |  | Влатко Симоновски | 16h |  | 16,000 |  |
| 15 | 2.3.2 | детализирање на "Испраќање пораки до менаџерот за услугата" | 1d? | 2014-11-28 | 2014-11-30 | 14 |  |  | 10d | 2d | finish no earlier than 2014-11-30 |  | Елена Камчевска | 8h |  | 8,000 |  |
| 16 | 2.3.3 | детализирање на "Ажурирање на податоци за рестораните" | 1d? | 2014-12-03 | 2014-12-03 | 15 |  |  | 42d |  | finish no earlier than 2014-12-03 |  | Влатко Симоновски | 8h |  | 8,000 |  |
| 17 | 2.3.4 | детализирање на "Одобрување на резервација" | 3d? | 2014-12-03 | 2014-12-05 |  |  |  | 37d | 0d | finish no earlier than 2014-12-05 |  | Елена Камчевска | 24h |  | 24,000 |  |
| 18 | 2.3.5 | детализирање на "Преглед на резервации" | 2d? | 2014-12-05 | 2014-12-08 |  |  |  | 39d |  | finish no earlier than 2014-12-08 |  | Влатко Симоновски | 16h |  | 16,000 |  |
| 19 | 2.3.6 | детализирање на "Пријавување на грешка/нефункционалност" | 3d? | 2014-12-08 | 2014-12-10 | 17 |  |  | 37d |  | start no earlier than 2014-12-08 |  | Елена Камчевска | 24h |  | 24,000 |  |
| 20 | 2.3.7 | детализирање на "Одговор на поплаки од менаџерот" | 3d? | 2014-12-10 | 2014-12-12 |  |  |  | 35d |  | finish no earlier than 2014-12-12 |  | Влатко Симоновски | 24h |  | 24,000 |  |
| 21 | 2.3.8 | детализирање на "Преглед на нарачки/специјалитети и нивно одоборување/откажување" | 2d? | 2014-12-12 | 2014-12-15 |  |  |  | 34d |  | finish no earlier than 2014-12-15 |  | Елена Камчевска | 16h |  | 16,000 |  |
| 22 | 2.4 | **реализации на use-case моделите** | 8d? | 2014-12-16 | 2014-12-25 |  |  |  | 26d |  |  |  |  | 104h |  | 104,000 |  |
| 23 | 2.4.1 | класен дијаграм за кориснички случај: креира резервација | 3d? | 2014-12-16 | 2014-12-18 |  |  |  | 26d | 0d | finish no earlier than 2014-12-18 |  | Елена Камчевска | 24h |  | 24,000 |  |
| 24 | 2.4.2 | класен дијаграм за кориснички случај: одобрува (потврдува) резервација | 3d? | 2014-12-16 | 2014-12-18 |  |  |  | 29d | 0d | finish no earlier than 2014-12-18 |  | Влатко Симоновски | 24h |  | 24,000 |  |
| 25 | 2.4.3 | секвенцен дијаграм за кориснички случај: креира резервација | 2d? | 2014-12-19 | 2014-12-22 | 24 |  |  | 29d |  | start no earlier than 2014-12-19 |  | Елена Камчевска | 16h |  | 16,000 |  |
| 26 | 2.4.4 | секвенцен дијаграм за кориснички случај: одобрува (потврдува) резервација | 2d? | 2014-12-19 | 2014-12-22 | 23 |  |  | 26d | 0d | start no earlier than 2014-12-19 |  | Влатко Симоновски | 16h |  | 16,000 |  |
| 27 | 2.4.5 | analysis model | 3d? | 2014-12-23 | 2014-12-25 | 26 |  |  | 26d |  | start no earlier than 2014-12-23 |  | Елена Камчевска | 24h |  | 24,000 |  |

| ID | WBS | Task | Duration | Start | Finish | Predecessors | Total slack | Free slack | Constraint | Deadline | Resources | Work | Cost |
| --- | --- | --- | --- | --- | --- | --- | --- | --- | --- | --- | --- | --- | --- |
| 28 | 2.5 | **дефинирање архитектура** | 3d? | 2014-12-26 | 2014-12-30 |  | 23d |  |  |  |  | 24h | 24,000 |
| 29 | 2.5.1 | анализа на кориснички случаи | 1d? | 2014-12-26 | 2014-12-26 |  | 23d | 0d | start no earlier than 2014-12-26 |  | Елена Камчевска | 8h | 8,000 |
| 30 | 2.5.2 | операциона анализа | 2d? | 2014-12-29 | 2014-12-30 | 29 | 23d |  | start no earlier than 2014-12-29 |  | Влатко Симоновски | 16h | 16,000 |
| 31 | 2.6 | **компоненти и извршување** | 21d? | 2015-01-02 | 2015-01-30 |  | -23d | 0d |  |  |  | 136h | 136,000 |
| 32 | 2.6.1 | избор на софтверкса платформа и UML дијаграми | 2d? | 2015-01-02 | 2015-01-05 |  | 13d | 0d | start no earlier than 2015-01-02 |  | Елена Камчевска | 16h | 16,000 |
| 33 | 2.6.2 | пренос на реализации на случаи на употреба од RUP Analysis Model | 5d? | 2015-01-06 | 2015-01-12 | 32 | 13d | 3d | finish no earlier than 2015-01-08 |  | Влатко Симоновски | 40h | 40,000 |
| 34 | 2.6.3 | компонентни дијаграми со пакети во системот и прелиминарни компоненти и потсистеми и релации меѓу нив | 1d? | 2015-01-16 | 2015-01-16 | 33 | 10d |  | finish no earlier than 2015-01-16 |  | Елена Камчевска | 8h | 8,000 |
| 35 | 2.6.4 | delployment дијаграм со архитектура на системот (уреди, сервери, компјутери, мрежа) | 4d? | 2015-01-20 | 2015-01-23 |  | -35d | 0d | start no earlier than 2015-01-20 | 2014-12-06 | Влатко Симоновски | 32h | 32,000 |
| 36 | 2.6.5 | дизајн на база на податоци | 5d? | 2015-01-26 | 2015-01-30 | 35 | 40d |  | finish no earlier than 2015-01-30 |  | Елена Камчевска | 40h | 40,000 |
| 37 | 3 | **Фаза 3: Construction** | 41d? | 2015-02-02 | 2015-03-30 |  | 24d |  |  |  |  | 352h | 688,000 |
| 38 | 3.1 | дизајн на компоненти | 20d? | 2015-02-02 | 2015-02-27 |  | 20d |  | finish no earlier than 2015-02-27 |  | Развивач 1 | 160h | 320,000 |
| 39 | 3.2 | дизајн на база | 20d? | 2015-02-02 | 2015-02-27 |  | 18d | 9d | finish no earlier than 2015-02-27 |  | Развивач 2 | 160h | 320,000 |
| 40 | 3.3 | изработка на прототип | 1d? | 2015-03-13 | 2015-03-13 | 39 | 9d |  | finish no earlier than 2015-03-13 |  | Развивач 1 | 8h | 16,000 |
| 41 | 3.4 | тестирање и евалуирање | 1d? | 2015-03-27 | 2015-03-27 | 40 | 25d |  | finish no earlier than 2015-03-27 |  | Развивач 2 | 8h | 16,000 |
| 42 | 3.5 | план за итерација | 2d? | 2015-03-27 | 2015-03-30 |  | 24d |  | start no earlier than 2015-03-27 |  | Елена Камчевска | 16h | 16,000 |
| 43 | 4 | **Фаза 4: Transition** | 23d? | 2015-04-01 | 2015-05-01 |  | 0d |  |  |  |  | 56h | 88,000 |
| 44 | 4.1 | deployment план | 3d? | 2015-04-01 | 2015-04-03 |  | 16d | 4d | finish no earlier than 2015-04-03 |  | Влатко Симоновски | 24h | 24,000 |
| 45 | 4.2 | исправување на грешки | 1d? | 2015-04-10 | 2015-04-10 | 44 | 12d | 9d | finish no earlier than 2015-04-10 |  | Развивач 1 | 8h | 16,000 |
| 46 | 4.3 | развој на дополнителни компоненти | 1d? | 2015-04-24 | 2015-04-24 | 45 | 3d |  | finish no earlier than 2015-04-24 |  | Развивач 2 | 8h | 16,000 |
| 47 | 4.4 | тестирање | 1d? | 2015-04-30 | 2015-04-30 | 46 | 0d |  | finish no earlier than 2015-04-30 |  | Развивач 1 | 8h | 16,000 |
| 48 | 4.5 | пуштање на апликацијата во употреба | 1d? | 2015-05-01 | 2015-05-01 | 47 | 0d |  |  |  | Развивач 2 | 8h | 16,000 |
